# Hiring New Employee 2-1

Schedule from MS Project, 2011-10-24 to 2011-12-09.

## Calendars

- Standard: Mon-Fri 08:00-12:00, 13:00-17:00; Sat-Sun off.

## Schedule

| ID | Task | Type | Duration | Start | Finish | Predecessors | Total slack |
| --- | --- | --- | --- | --- | --- | --- | --- |
| 1 | Write job description |  | 2d | 2011-10-24 | 2011-10-25 |  | 0d |
| 2 | Notify departmental recruiter |  | 1d | 2011-10-26 | 2011-10-26 | 1 | 0d |
| 3 | Post job internally |  | 5d | 2011-10-27 | 2011-11-02 | 2 | 0d |
| 4 | Post job externally |  | 5d | 2011-10-27 | 2011-11-02 | 3SS | 0d |
| 5 | Collect resumes |  | 10d | 2011-11-03 | 2011-11-16 | 4 | 0d |
| 6 | Review resumes |  | 5d | 2011-11-17 | 2011-11-23 | 5 | 0d |
| 7 | Set up interviews |  | 3d | 2011-11-24 | 2011-11-28 | 6 | 0d |
| 8 | Conduct interviews |  | 8d | 2011-11-29 | 2011-12-08 | 7 | 0d |
| 9 | Select candidate |  | 1d | 2011-12-09 | 2011-12-09 | 8 | 0d |
| 10 | Make offer | milestone | 0d | 2011-12-09 | 2011-12-09 | 9 | 0d |
